# 2016_Spring_I2MAP_EngineeringScheduleKRR_3_29_16

Schedule from MS Project, 2016-02-04 to 2016-05-16, A marks actual dates.
Hewlett-Packard Company

## Calendars

- Standard: Mon-Fri 08:00-12:00, 13:00-17:00; Sat-Sun off.

## Resources

| Resource |
| --- |
| Mark Chaffey |
| Rich Henthorn |
| François Cazenave |
| Machine Shop |
| E Tech |
| M tech |
| Kim Reisenbichler |
| AUV tech |
| Mike McCann |
| Rob McEwen |
| Jon Erickson |
| Chinese Shop |

## Schedule

| ID | WBS | Task | Type | Duration | Start | Finish | Predecessors | Complete | Remaining | Total slack | Free slack | Constraint | Resources | Work | Actual work |
| --- | --- | --- | --- | --- | --- | --- | --- | --- | --- | --- | --- | --- | --- | --- | --- |
| 1 | 1 | **Original dome design evaluation (Round 2)** |  | 65d? | 2016-02-05 A | 2016-05-05 |  | 31% | 44.85d? | 1.33d |  |  |  | 540.8h | 92.4h |
| 2 | 1.1 | Evaluate possible causes of prior failure |  | 4d? | 2016-02-05 A | 2016-02-10 A |  | 100% |  |  |  | finish no earlier than 2016-02-10 | François Cazenave [50%]; Mark Chaffey [20%] | 38.4h | 38.4h |
| 3 | 1.2 | Re-run simulations to verify results of tests 1 & 2 |  | 12.5d? | 2016-02-15 A | 2016-03-02 A | 2 | 100% |  |  |  | start no earlier than 2016-02-15 |  |  |  |
| 4 | 1.3 | Redesign solid model of dome support |  | 15d | 2016-03-03 A | 2016-03-23 | 3 | 75% | 3.75d | -3d | 0d | start no earlier than 2016-03-03 | François Cazenave [60%] | 72h | 54h |
| 5 | 1.4 | Perform complete FEA analysis of design #3 |  | 5d | 2016-03-21 | 2016-03-25 | 4 |  |  | -3d | 0d | start no later than 2016-03-21 | François Cazenave | 40h |  |
| 6 | 1.5 | Perform alternate FEA analysis of design #3 |  | 7d | 2016-03-28 | 2016-04-05 | 4, 5 |  |  | 1.33d | 0d | start no earlier than 2016-03-28 | Jon Erickson | 56h |  |
| 7 | 1.6 | Meet and evaluate new design options | milestone | 0d | 2016-04-05 | 2016-04-05 | 6, 5 |  |  | 1.33d | 0d | start no earlier than 2016-03-07 |  |  |  |
| 8 | 1.7 | Complete fabrication drawings |  | 3d | 2016-04-06 | 2016-04-08 | 7 |  |  | 1.33d | 0d | finish no earlier than 2016-04-01 | François Cazenave [60%] | 14.4h |  |
| 9 | 1.8 | Fabricate new dome support |  | 10d | 2016-04-11 | 2016-04-22 | 8 |  |  | 1.33d | 0d | start no earlier than 2016-04-11 | Machine Shop | 80h |  |
| 10 | 1.9 | Domes (2) away for seat leveling and polishing | manual | 24d? | 2016-03-22 | 2016-04-22 |  |  |  |  |  | start no earlier than 2016-03-22 | Chinese Shop | 192h |  |
| 11 | 1.10 | Prep domes #3 & 4 and test rig for Pressure test |  | 5d | 2016-04-25 | 2016-04-29 | 9, 10 |  |  | 1.33d | 0d | finish no earlier than 2016-02-16 | François Cazenave [60%] | 24h |  |
| 12 | 1.11 | Pressure test of domes at Pt. Hueneme |  | 4d | 2016-05-02 | 2016-05-05 | 11 |  |  | 1.33d | 0d | finish no earlier than 2016-02-22 | François Cazenave [75%] | 24h |  |
| 13 | 1.12 | Review of results and determine how to proceed | milestone | 0d | 2016-05-05 | 2016-05-05 | 12 |  |  | 1.33d | 0d | start no earlier than 2016-03-07 | François Cazenave [60%]; Kim Reisenbichler; Mark Chaffey [60%] |  |  |
| 14 | 2 | **Lab Testing** |  | 68d? | 2016-02-04 A | 2016-05-09 |  | 15% | 57.82d? | 0d |  |  |  | 139.95h | 18.55h |
| 15 | 2.1 | **CTD System** |  | 44d? | 2016-02-04 A | 2016-04-05 |  | 72% | 12.21d? | 20.33d |  |  |  | 25.55h | 7.95h |
| 16 | 2.1.1 | Full CTD test set-up |  | 1.5d? | 2016-02-04 A | 2016-02-05 A |  | 100% |  |  |  | start no earlier than 2016-02-04 | Mark Chaffey [60%] | 7.2h | 7.2h |
| 17 | 2.1.2 | Document CTD data load path |  | 0.1d? | 2016-02-23 A | 2016-02-23 A | 16 | 100% |  |  |  | start no earlier than 2016-02-23 | Mark Chaffey [60%]; Mike McCann | 0.75h | 0.75h |
| 18 | 2.1.3 | Config file for CTD sensors |  | 1d? | 2016-03-18 A | 2016-03-18 A |  | 100% |  |  |  | finish no earlier than 2016-03-18 |  |  |  |
| 19 | 2.1.4 | End-to-end CTD data verification |  | 1d | 2016-04-05 | 2016-04-05 | 17 |  |  | 20.33d | 0d | start no earlier than 2016-04-05 | Mark Chaffey [60%]; Rich Henthorn [60%]; Rob McEwen | 17.6h |  |
| 20 | 2.2 | **Verify camera Settings** |  | 1.46d? | 2016-03-28 | 2016-03-29 |  |  |  | 25.88d |  |  |  | 11h |  |
| 21 | 2.2.1 | Test persistance over power cycle |  | 1.46d? | 2016-03-28 | 2016-03-29 |  |  |  | 25.88d | 5.54d | start no earlier than 2016-03-28 | Mark Chaffey [60%] | 7h |  |
| 22 | 2.2.2 | Install new camera firmware |  | 0.83d | 2016-03-28 | 2016-03-28 |  |  |  | 26.5d | 6.17d | start no earlier than 2016-03-28 | Mark Chaffey [60%] | 4h |  |
| 23 | 2.3 | **Camera Iris and Lighting Control** |  | 1d? | 2016-04-04 | 2016-04-04 |  |  |  |  |  |  |  | 27.2h |  |
| 24 | 2.3.1 | Verify light switching and intensity |  | 1d | 2016-04-04 | 2016-04-04 |  |  |  | 21.33d | 1d | start no earlier than 2016-04-04 | Mark Chaffey [60%]; Rich Henthorn [60%] | 9.6h |  |
| 25 | 2.3.2 | Verify iris control and no light interference |  | 1d? | 2016-04-04 | 2016-04-04 |  |  |  | 21.33d | 1d | start no earlier than 2016-04-04 | Mark Chaffey [60%]; Rich Henthorn [60%]; Rob McEwen | 17.6h |  |

| ID | WBS | Task | Type | Duration | Start | Finish | Predecessors | Complete | Remaining | Total slack | Free slack | Constraint | Resources | Work | Actual work |
| --- | --- | --- | --- | --- | --- | --- | --- | --- | --- | --- | --- | --- | --- | --- | --- |
| 26 | 2.4 | **Mission script development** |  | 26d | 2016-04-04 | 2016-05-09 |  |  |  |  |  |  |  | 36h |  |
| 27 | 2.4.1 | Mission script development |  | 10d | 2016-04-04 | 2016-04-15 |  |  |  | 12.33d | 6d | start no earlier than 2016-04-04 | Rob McEwen [15%]; Kim Reisenbichler [15%]; Rich Henthorn [15%] | 36h |  |
| 28 | 2.4.2 | Mission script review | milestone | 0d | 2016-04-26 | 2016-04-26 | 27 |  |  | 6.33d | 0d | start no earlier than 2016-04-26 |  |  |  |
| 29 | 2.5 | **Misc. functions** |  | 20d? | 2016-04-05 A | 2016-05-02 |  | 17% | 16.67d? |  |  |  |  | 40.2h | 10.6h |
| 30 | 2.5.1 | Test light brightness and current |  | 0.5d | 2016-04-05 | 2016-04-05 |  |  |  | 20.83d | 0.5d | start no earlier than 2016-04-05 | Mark Chaffey [60%] | 2.4h |  |
| 31 | 2.5.2 | Data logging |  | 1d? | 2016-04-05 | 2016-04-05 |  |  |  | 20.33d | 0d | start no earlier than 2016-04-05 | Rich Henthorn [60%] | 4.8h |  |
| 32 | 2.5.3 | Water alarm abort verification |  | 1d? | 2016-04-05 A | 2016-04-05 |  | 75% | 0.25d? | 20.33d | 0d | start no earlier than 2016-03-07 | Rich Henthorn [60%]; Rob McEwen; Mark Chaffey [60%] | 13.8h | 10.6h |
| 33 | 2.5.4 | Verify camera temperature reading |  | 1d? | 2016-04-05 | 2016-04-05 |  |  |  | 20.33d | 0d | start no earlier than 2016-04-05 | Rich Henthorn [60%]; Mark Chaffey [60%] | 9.6h |  |
| 34 | 2.5.5 | Debug video peak and mean readings |  | 1d? | 2016-04-05 | 2016-04-05 |  |  |  | 20.33d | 0d | start no earlier than 2016-04-05 | Rich Henthorn [60%]; Mark Chaffey [60%] | 9.6h |  |
| 35 | 2.5.6 | Lab unit testing complete | milestone | 0d | 2016-04-05 | 2016-04-05 | 32, 31, 25, 24, 21, 19, 33, 34, 30, 22 |  |  | 20.33d | 14d | start no earlier than 2016-04-05 |  |  |  |
| 36 | 3 | VM closed loop simulation testing |  | 3d | 2016-04-26 | 2016-04-28 | 28, 35 |  |  | 6.33d | 0d | start no earlier than 2016-02-02 | Rob McEwen; Rich Henthorn [60%]; Mark Chaffey [60%] | 52.8h |  |
| 37 | 4 | Code freeze | milestone | 0d | 2016-04-28 | 2016-04-28 | 36 |  |  | 6.33d | 0d | start no earlier than 2016-04-26 |  |  |  |
| 38 | 5 | All lab testing complete | milestone | 0d | 2016-04-28 | 2016-04-28 | 37 |  |  | 6.33d | 5d | start no earlier than 2016-02-02 |  |  |  |
| 39 | 6 | Assemble complete camera housing |  | 1.67d | 2016-05-06 | 2016-05-09 | 13, 38 |  |  | 1.33d | 0d | start no earlier than 2016-05-01 | François Cazenave [60%]; Mark Chaffey [60%] | 12.8h |  |
| 40 | 7 | **Tank testing with full vehicle running mission script** |  | 3d? | 2016-05-09 | 2016-05-11 |  |  |  |  |  |  |  | 66.4h |  |
| 41 | 7.1 | Assemble full AUV system |  | 1d | 2016-05-09 | 2016-05-10 | 39 |  |  | 1.33d | 0d |  | AUV tech; François Cazenave [60%]; Mark Chaffey [60%] | 17.6h |  |
| 42 | 7.2 | Verify mission scripts |  | 1d | 2016-05-10 | 2016-05-11 | 41 |  |  | 1.33d | 0.33d | start no earlier than 2016-02-02 | Rob McEwen; Rich Henthorn [60%]; Mark Chaffey [60%] | 17.6h |  |
| 43 | 7.3 | Confirm all camera operations |  | 1d | 2016-05-10 | 2016-05-11 | 41 |  |  | 1.33d | 0.33d | start no earlier than 2016-02-02 | Rob McEwen [20%]; Rich Henthorn [60%]; Mark Chaffey [60%] | 5.6h |  |
| 44 | 7.4 | Verify lighting is optimized |  | 1d? | 2016-05-11 | 2016-05-11 | 41 |  |  | 1d | 0d | start no earlier than 2016-05-11 | François Cazenave [60%]; Kim Reisenbichler; Mark Chaffey [60%] | 17.6h |  |
| 45 | 7.5 | Ballast and Trim |  | 1d? | 2016-05-11 | 2016-05-11 | 41 |  |  | 1d | 0d | start no earlier than 2016-05-11 | AUV tech | 8h |  |
| 46 | 7.6 | Tank testing complete | milestone | 0d | 2016-05-11 | 2016-05-11 | 45, 43, 44, 42 |  |  | 1d | 0d | start no earlier than 2016-02-02 |  |  |  |
| 47 | 8 | Load AUV for cruise |  | 1d | 2016-05-12 | 2016-05-12 | 46 |  |  | 1d |  |  | AUV tech | 8h |  |
| 48 | 9 | Cruise for transect mission | milestone | 0d | 2016-05-16 | 2016-05-16 | 47 |  |  | 0d |  | must start on 2016-05-16 |  |  |  |
