# 2016_Spring_I2MAP_EngineeringScheduleKRR_3_8_16

Schedule from MS Project, 2016-02-04 to 2016-05-16, A marks actual dates.
Hewlett-Packard Company

## Calendars

- Standard: Mon-Fri 08:00-12:00, 13:00-17:00; Sat-Sun off.

## Resources

| Resource |
| --- |
| Mark Chaffey |
| Rich Henthorn |
| François Cazenave |
| Machine Shop |
| E Tech |
| M tech |
| Kim Reisenbichler |
| AUV tech |
| Mike McCann |
| Rob McEwen |
| Jon Erickson |

## Schedule

| ID | WBS | Task | Type | Duration | Start | Finish | Predecessors | Complete | Remaining | Total slack | Free slack | Constraint | Resources | Work | Actual work |
| --- | --- | --- | --- | --- | --- | --- | --- | --- | --- | --- | --- | --- | --- | --- | --- |
| 1 | 1 | **Original dome design evaluation (Round 2)** |  | 54.5d? | 2016-02-05 A | 2016-04-21 |  | 34% | 35.86d? | 9.83d |  |  |  | 269.6h | 52.8h |
| 2 | 1.1 | Evaluate possible causes of prior failure |  | 4d? | 2016-02-05 A | 2016-02-10 A |  | 100% |  |  |  | finish no earlier than 2016-02-10 | François Cazenave [50%]; Mark Chaffey [20%] | 38.4h | 38.4h |
| 3 | 1.2 | Re-run simulations to verify results of tests 1 & 2 |  | 12.5d? | 2016-02-15 A | 2016-03-02 A | 2 | 100% |  |  |  | start no earlier than 2016-02-15 |  |  |  |
| 4 | 1.3 | Redesign solid model of dome support |  | 9.5d | 2016-03-03 A | 2016-03-16 | 3 | 32% | 6.5d | 9.83d | 0d | start no earlier than 2016-03-03 | François Cazenave [60%] | 45.6h | 14.4h |
| 5 | 1.4 | Perform complete FEA analysis of design #3 |  | 5d | 2016-03-16 | 2016-03-23 | 4 |  |  | 9.83d | 0d | start no earlier than 2016-03-07 | François Cazenave [60%] | 24h |  |
| 6 | 1.5 | Perform alternate FEA analysis of design #3 |  | 5d | 2016-03-16 | 2016-03-23 | 4 |  |  | 9.83d | 0d | start no earlier than 2016-03-07 | Jon Erickson [60%] | 24h |  |
| 7 | 1.6 | Meet and evaluate new design options | milestone | 0d | 2016-03-23 | 2016-03-23 | 6, 5 |  |  | 9.83d | 0d | start no earlier than 2016-03-07 |  |  |  |
| 8 | 1.7 | Complete fabrication drawings |  | 3d | 2016-03-23 | 2016-03-28 | 7 |  |  | 9.83d | 0d | start no earlier than 2016-03-07 | François Cazenave [60%] | 14.4h |  |
| 9 | 1.8 | Fabricate new dome support |  | 10d | 2016-03-28 | 2016-04-11 | 8 |  |  | 9.83d | 0d | start no earlier than 2016-03-07 | Machine Shop | 80h |  |
| 10 | 1.9 | Prepare dome #3 and test rig for test |  | 4d | 2016-04-11 | 2016-04-15 | 9 |  |  | 9.83d | 0d | finish no earlier than 2016-02-16 | François Cazenave [60%] | 19.2h |  |
| 11 | 1.10 | Pressure test of domes at Pt. Hueneme |  | 4d | 2016-04-15 | 2016-04-21 | 10 |  |  | 9.83d | 0d | finish no earlier than 2016-02-22 | François Cazenave [75%] | 24h |  |
| 12 | 1.11 | Review of results and determine how to proceed | milestone | 0d | 2016-04-21 | 2016-04-21 | 11 |  |  | 9.83d | 0d | start no earlier than 2016-03-07 | François Cazenave [60%]; Kim Reisenbichler; Mark Chaffey [60%] |  |  |
| 13 | 2 | **Lab Testing** |  | 49d? | 2016-02-04 A | 2016-04-13 |  | 11% | 43.85d? | 23d |  |  |  | 139.95h | 18.55h |
| 14 | 2.1 | **CTD System** |  | 24d? | 2016-02-04 A | 2016-03-08 |  | 45% | 13.32d? | 48d |  |  |  | 25.55h | 7.95h |
| 15 | 2.1.1 | Full CTD test set-up |  | 1.5d? | 2016-02-04 A | 2016-02-05 A |  | 100% |  |  |  | start no earlier than 2016-02-04 | Mark Chaffey [60%] | 7.2h | 7.2h |
| 16 | 2.1.2 | Document CTD data load path |  | 0.1d? | 2016-02-23 A | 2016-02-23 A | 15 | 100% |  |  |  | start no earlier than 2016-02-23 | Mark Chaffey [60%]; Mike McCann | 0.75h | 0.75h |
| 17 | 2.1.3 | Config file for ???? |  | 1d? | 2016-03-08 | 2016-03-08 |  |  |  | 48d |  | start no earlier than 2016-03-08 |  |  |  |
| 18 | 2.1.4 | End-to-end CTD data verification |  | 1d | 2016-03-07 | 2016-03-07 | 16 |  |  | 39.33d | 1d | start no earlier than 2016-03-07 | Mark Chaffey [60%]; Rich Henthorn [60%]; Rob McEwen | 17.6h |  |
| 19 | 2.2 | **Verify camera Settings** |  | 1.46d? | 2016-03-07 | 2016-03-08 |  |  |  | 38.88d |  |  |  | 11h |  |
| 20 | 2.2.1 | Test persistance over power cycle |  | 1.46d? | 2016-03-07 | 2016-03-08 |  |  |  | 38.88d | 0.54d | start no earlier than 2016-03-07 | Mark Chaffey [60%] | 7h |  |
| 21 | 2.2.2 | Install new camera firmware |  | 0.83d | 2016-03-07 | 2016-03-07 |  |  |  | 39.5d | 1.17d | start no earlier than 2016-03-07 | Mark Chaffey [60%] | 4h |  |
| 22 | 2.3 | **Camera Iris and Lighting Control** |  | 1d? | 2016-03-08 | 2016-03-08 |  |  |  | 38.33d |  |  |  | 27.2h |  |
| 23 | 2.3.1 | Verify light switching and intensity |  | 1d | 2016-03-08 | 2016-03-08 |  |  |  | 38.33d | 0d | start no earlier than 2016-03-07 | Mark Chaffey [60%]; Rich Henthorn [60%] | 9.6h |  |
| 24 | 2.3.2 | Verify iris control and no light interference |  | 1d? | 2016-03-08 | 2016-03-08 |  |  |  | 38.33d | 0d | start no earlier than 2016-03-07 | Mark Chaffey [60%]; Rich Henthorn [60%]; Rob McEwen | 17.6h |  |

| ID | WBS | Task | Type | Duration | Start | Finish | Predecessors | Complete | Remaining | Total slack | Free slack | Constraint | Resources | Work | Actual work |
| --- | --- | --- | --- | --- | --- | --- | --- | --- | --- | --- | --- | --- | --- | --- | --- |
| 25 | 2.4 | **Mission script development** |  | 26d | 2016-03-08 | 2016-04-13 |  |  |  | 0d |  |  |  | 36h |  |
| 26 | 2.4.1 | Mission script development |  | 10d | 2016-03-08 | 2016-03-21 |  |  |  | 16d |  | start no earlier than 2016-03-07 | Rob McEwen [15%]; Kim Reisenbichler [15%]; Rich Henthorn [15%] | 36h |  |
| 27 | 2.4.2 | Mission script review | milestone | 0d | 2016-04-13 | 2016-04-13 | 26 |  |  | 0d |  | must start on 2016-04-13 |  |  |  |
| 28 | 2.5 | **Misc. functions** |  | 1d? | 2016-03-08 A | 2016-03-08 |  | 17% | 0.83d? | 38.33d |  |  |  | 40.2h | 10.6h |
| 29 | 2.5.1 | Test light brightness and current |  | 0.5d | 2016-03-08 | 2016-03-08 |  |  |  | 38.83d | 0.5d | start no earlier than 2016-03-07 | Mark Chaffey [60%] | 2.4h |  |
| 30 | 2.5.2 | Data logging |  | 1d? | 2016-03-08 | 2016-03-08 |  |  |  | 38.33d | 0d | start no earlier than 2016-03-07 | Rich Henthorn [60%] | 4.8h |  |
| 31 | 2.5.3 | Water alarm abort verification |  | 1d? | 2016-03-08 A | 2016-03-08 |  | 75% | 0.25d? | 38.33d | 0d | start no earlier than 2016-03-07 | Rich Henthorn [60%]; Rob McEwen; Mark Chaffey [60%] | 13.8h | 10.6h |
| 32 | 2.5.4 | Verify camera temperature reading |  | 1d? | 2016-03-08 | 2016-03-08 |  |  |  | 38.33d | 0d | start no earlier than 2016-03-07 | Rich Henthorn [60%]; Mark Chaffey [60%] | 9.6h |  |
| 33 | 2.5.5 | Debug video peak and mean readings |  | 1d? | 2016-03-08 | 2016-03-08 |  |  |  | 38.33d | 0d | start no earlier than 2016-03-07 | Rich Henthorn [60%]; Mark Chaffey [60%] | 9.6h |  |
| 34 | 2.5.6 | Lab unit testing complete | milestone | 0d | 2016-03-08 | 2016-03-08 | 31, 30, 24, 23, 20, 18, 32, 33, 29, 21 |  |  | 38.33d | 25d | start no earlier than 2016-02-02 |  |  |  |
| 35 | 3 | VM closed loop simulation testing |  | 3d | 2016-04-13 | 2016-04-15 | 27, 34 |  |  | 13.33d | 0d | start no earlier than 2016-02-02 | Rob McEwen; Rich Henthorn [60%]; Mark Chaffey [60%] | 52.8h |  |
| 36 | 4 | Code freeze | milestone | 0d | 2016-04-15 | 2016-04-15 | 35 |  |  | 13.33d | 0d | start no earlier than 2016-02-02 |  |  |  |
| 37 | 5 | All lab testing complete | milestone | 0d | 2016-04-15 | 2016-04-15 | 36 |  |  | 13.33d | 3.5d | start no earlier than 2016-02-02 |  |  |  |
| 38 | 6 | Assemble complete camera housing |  | 1.67d | 2016-04-21 | 2016-04-25 | 12, 37 |  |  | 9.83d |  | start no earlier than 2016-03-07 | François Cazenave [60%]; Mark Chaffey [60%] | 12.8h |  |
| 39 | 7 | **Tank testing with full vehicle running mission script** |  | 3d? | 2016-05-09 | 2016-05-11 |  |  |  | 0d |  |  |  | 66.4h |  |
| 40 | 7.1 | Assemble full AUV system |  | 1d | 2016-05-09 | 2016-05-09 | 38 |  |  | 0d |  | must start on 2016-05-09 | AUV tech; François Cazenave [60%]; Mark Chaffey [60%] | 17.6h |  |
| 41 | 7.2 | Verify mission scripts |  | 1d | 2016-05-10 | 2016-05-10 | 40 |  |  | 1d |  | start no earlier than 2016-02-02 | Rob McEwen; Rich Henthorn [60%]; Mark Chaffey [60%] | 17.6h |  |
| 42 | 7.3 | Confirm all camera operations |  | 1d | 2016-05-10 | 2016-05-10 | 40 |  |  | 1d |  | start no earlier than 2016-02-02 | Rob McEwen [20%]; Rich Henthorn [60%]; Mark Chaffey [60%] | 5.6h |  |
| 43 | 7.4 | Verify lighting is optimized |  | 1d? | 2016-05-11 | 2016-05-11 | 40 |  |  | 0d |  | start no earlier than 2016-05-11 | François Cazenave [60%]; Kim Reisenbichler; Mark Chaffey [60%] | 17.6h |  |
| 44 | 7.5 | Ballast and Trim |  | 1d? | 2016-05-11 | 2016-05-11 | 40 |  |  | 0d |  | start no earlier than 2016-05-11 | AUV tech | 8h |  |
| 45 | 7.6 | Tank testing complete | milestone | 0d | 2016-05-11 | 2016-05-11 | 44, 42, 43, 41 |  |  | 0d |  | start no earlier than 2016-02-02 |  |  |  |
| 46 | 8 | Load AUV for cruise |  | 1d | 2016-05-12 | 2016-05-12 | 45 |  |  | 0d |  | must start on 2016-05-12 | AUV tech | 8h |  |
| 47 | 9 | Cruise for transect mission | milestone | 0d | 2016-05-16 | 2016-05-16 | 46 |  |  | 0d |  | must start on 2016-05-16 |  |  |  |
