# 2016_Spring_I2MAP_EngineeringScheduleKRR_4_19_16

Schedule from MS Project, 2016-02-04 to 2016-12-12, A marks actual dates.
Hewlett-Packard Company

## Calendars

- Standard: Mon-Fri 08:00-12:00, 13:00-17:00; Sat-Sun off.

## Resources

| Resource |
| --- |
| Mark Chaffey |
| Rich Henthorn |
| François Cazenave |
| Machine Shop |
| E Tech |
| M tech |
| Kim Reisenbichler |
| AUV tech |
| Mike McCann |
| Rob McEwen |
| Jon Erickson |
| Chinese Shop |

## Schedule

| ID | WBS | Task | Type | Duration | Start | Finish | Predecessors | Complete | Remaining | Total slack | Free slack | Constraint | Resources | Work | Actual work |
| --- | --- | --- | --- | --- | --- | --- | --- | --- | --- | --- | --- | --- | --- | --- | --- |
| 1 | 1 | **Original dome design evaluation (Round 2)** |  | 103d? | 2016-02-05 A | 2016-06-28 |  | 37% | 65.07d? | 118d |  |  |  | 609.6h | 162.8h |
| 2 | 1.1 | Evaluate possible causes of prior failure |  | 4d? | 2016-02-05 A | 2016-02-10 A |  | 100% |  |  |  | finish no earlier than 2016-02-10 | François Cazenave [50%]; Mark Chaffey [20%] | 38.4h | 38.4h |
| 3 | 1.2 | Re-run simulations to verify results of tests 1 & 2 |  | 12.5d? | 2016-02-15 A | 2016-03-02 A | 2 | 100% |  |  |  | start no earlier than 2016-02-15 |  |  |  |
| 4 | 1.3 | Redesign solid model of dome support |  | 15d | 2016-03-03 A | 2016-03-23 | 3 | 75% | 3.75d | -3d | 0d | start no earlier than 2016-03-03 | François Cazenave [60%] | 72h | 54h |
| 5 | 1.4 | Perform complete FEA analysis of design #3 |  | 5d | 2016-03-21 | 2016-03-25 | 4 |  |  | -3d | 0d | start no later than 2016-03-21 | François Cazenave | 40h |  |
| 6 | 1.5 | Perform alternate FEA analysis of design #3 |  | 7d | 2016-03-28 A | 2016-04-05 A | 4, 5 | 100% |  |  |  | start no earlier than 2016-03-28 | Jon Erickson | 56h | 56h |
| 7 | 1.6 | Meet and evaluate new design options | milestone | 0d | 2016-04-05 | 2016-04-05 | 6, 5 |  |  | 178d |  | start no earlier than 2016-03-07 |  |  |  |
| 8 | 1.7 | Complete fabrication drawings |  | 3d | 2016-04-06 A | 2016-04-08 A | 7 | 100% |  |  |  | finish no earlier than 2016-04-01 | François Cazenave [60%] | 14.4h | 14.4h |
| 9 | 1.8 | Fabricate new dome support |  | 5d | 2016-04-26 | 2016-05-02 | 8 |  |  | 0.33d | 0d | start no earlier than 2016-04-26 | Machine Shop | 40h |  |
| 10 | 1.9 | Prepare 1 dome and support for pressure testing |  | 2d | 2016-05-03 | 2016-05-04 | 9 |  |  | 0.33d | 0d |  | François Cazenave [60%]; Kim Reisenbichler | 25.6h |  |
| 11 | 1.10 | Pressure test of dome at Pt. Hueneme |  | 2d | 2016-05-05 | 2016-05-06 | 10 |  |  | 0.33d | 0d |  | François Cazenave [60%] | 9.6h |  |
| 12 | 1.11 | Domes (2) away for seat leveling and polishing | manual | 35d | 2016-03-22 | 2016-05-09 |  |  |  |  |  | start no earlier than 2016-03-22 | Chinese Shop | 280h |  |
| 13 | 1.12 | Fabricate additional dome support |  | 6d | 2016-06-13 | 2016-06-20 |  |  |  | 118d | 0d | start no earlier than 2016-06-13 |  |  |  |
| 14 | 1.13 | Prep dome #4 and test rig for Pressure test |  | 2d | 2016-06-21 | 2016-06-22 | 12, 13 |  |  | 118d | 0d | start no earlier than 2016-05-23 | François Cazenave [60%] | 9.6h |  |
| 15 | 1.14 | Extensive pressure test of domes #3 & #4 at Pt. Hueneme |  | 4d | 2016-06-23 | 2016-06-28 | 14 |  |  | 118d | 0d | finish no earlier than 2016-02-22 | François Cazenave [75%] | 24h |  |
| 16 | 1.15 | Review of results and determine how to proceed | milestone | 0d | 2016-06-28 | 2016-06-28 | 15 |  |  | 118d |  | start no earlier than 2016-03-07 | François Cazenave [60%]; Kim Reisenbichler; Mark Chaffey [60%] |  |  |
| 17 | 2 | **Lab Testing** |  | 71d? | 2016-02-04 A | 2016-05-12 |  | 15% | 60.37d? | 0d |  |  |  | 139.95h | 18.55h |
| 18 | 2.1 | **CTD System** |  | 57d? | 2016-02-04 A | 2016-04-22 |  | 72% | 15.81d? | 7.33d |  |  |  | 25.55h | 7.95h |
| 19 | 2.1.1 | Full CTD test set-up |  | 1.5d? | 2016-02-04 A | 2016-02-05 A |  | 100% |  |  |  | start no earlier than 2016-02-04 | Mark Chaffey [60%] | 7.2h | 7.2h |
| 20 | 2.1.2 | Document CTD data load path |  | 0.1d? | 2016-02-23 A | 2016-02-23 A | 19 | 100% |  |  |  | start no earlier than 2016-02-23 | Mark Chaffey [60%]; Mike McCann | 0.75h | 0.75h |
| 21 | 2.1.3 | Config file for CTD sensors |  | 1d? | 2016-03-18 A | 2016-03-18 A |  | 100% |  |  |  | finish no earlier than 2016-03-18 |  |  |  |
| 22 | 2.1.4 | End-to-end CTD data verification |  | 1d | 2016-04-22 | 2016-04-22 | 20 |  |  | 7.33d | 0d | start no earlier than 2016-04-22 | Mark Chaffey [60%]; Rich Henthorn [60%]; Rob McEwen | 17.6h |  |
| 23 | 2.2 | **Verify camera Settings** |  | 1.46d? | 2016-04-20 | 2016-04-21 |  |  |  | 8.88d |  |  |  | 11h |  |
| 24 | 2.2.1 | Test persistance over power cycle |  | 1.46d? | 2016-04-20 | 2016-04-21 |  |  |  | 8.88d | 1.54d | start no earlier than 2016-04-20 | Mark Chaffey [60%] | 7h |  |
| 25 | 2.2.2 | Install new camera firmware |  | 0.83d | 2016-04-20 | 2016-04-20 |  |  |  | 9.5d | 2.17d | start no earlier than 2016-04-20 | Mark Chaffey [60%] | 4h |  |

| ID | WBS | Task | Type | Duration | Start | Finish | Predecessors | Complete | Remaining | Total slack | Free slack | Constraint | Resources | Work | Actual work |
| --- | --- | --- | --- | --- | --- | --- | --- | --- | --- | --- | --- | --- | --- | --- | --- |
| 26 | 2.3 | **Camera Iris and Lighting Control** |  | 1d? | 2016-04-20 | 2016-04-20 |  |  |  |  |  |  |  | 27.2h |  |
| 27 | 2.3.1 | Verify light switching and intensity |  | 1d | 2016-04-20 | 2016-04-20 |  |  |  | 9.33d | 2d | start no earlier than 2016-04-20 | Mark Chaffey [60%]; Rich Henthorn [60%] | 9.6h |  |
| 28 | 2.3.2 | Verify iris control and no light interference |  | 1d? | 2016-04-20 | 2016-04-20 |  |  |  | 9.33d | 2d | start no earlier than 2016-04-20 | Mark Chaffey [60%]; Rich Henthorn [60%]; Rob McEwen | 17.6h |  |
| 29 | 2.4 | **Mission script development** |  | 10d | 2016-04-20 | 2016-05-03 |  |  |  |  |  |  |  | 36h |  |
| 30 | 2.4.1 | Mission script development |  | 10d | 2016-04-20 | 2016-05-03 |  |  |  | 0.33d | 0d | start no earlier than 2016-04-20 | Rob McEwen [15%]; Kim Reisenbichler [15%]; Rich Henthorn [15%] | 36h |  |
| 31 | 2.4.2 | Mission script review | milestone | 0d | 2016-05-03 | 2016-05-03 | 30 |  |  | 0.33d | 0d | start no earlier than 2016-04-20 |  |  |  |
| 32 | 2.5 | **Misc. functions** |  | 15d | 2016-04-22 A | 2016-05-12 |  | 17% | 12.5d |  |  |  |  | 40.2h | 10.6h |
| 33 | 2.5.1 | Test light brightness and current |  | 0.5d | 2016-04-22 | 2016-04-22 |  |  |  | 7.83d | 0.5d | start no earlier than 2016-04-22 | Mark Chaffey [60%] | 2.4h |  |
| 34 | 2.5.2 | Data logging |  | 1d? | 2016-04-22 | 2016-04-22 |  |  |  | 7.33d | 0d | start no earlier than 2016-04-22 | Rich Henthorn [60%] | 4.8h |  |
| 35 | 2.5.3 | Water alarm abort verification |  | 1d? | 2016-04-22 A | 2016-04-22 |  | 75% | 0.25d? | 7.33d | 0d | start no earlier than 2016-03-07 | Rich Henthorn [60%]; Rob McEwen; Mark Chaffey [60%] | 13.8h | 10.6h |
| 36 | 2.5.4 | Verify camera temperature reading |  | 1d? | 2016-04-22 | 2016-04-22 |  |  |  | 7.33d | 0d | start no earlier than 2016-04-22 | Rich Henthorn [60%]; Mark Chaffey [60%] | 9.6h |  |
| 37 | 2.5.5 | Debug video peak and mean readings |  | 1d? | 2016-04-22 | 2016-04-22 |  |  |  | 7.33d | 0d | start no earlier than 2016-04-22 | Rich Henthorn [60%]; Mark Chaffey [60%] | 9.6h |  |
| 38 | 2.5.6 | Lab unit testing complete | milestone | 0d | 2016-04-22 | 2016-04-22 | 35, 34, 28, 27, 24, 22, 36, 37, 33, 25 |  |  | 7.33d | 7d | start no earlier than 2016-04-05 |  |  |  |
| 39 | 3 | VM closed loop simulation testing |  | 3d | 2016-05-04 | 2016-05-06 | 31, 38 |  |  | 0.33d | 0d | start no earlier than 2016-02-02 | Rob McEwen; Rich Henthorn [60%]; Mark Chaffey [60%] | 52.8h |  |
| 40 | 4 | Code freeze | milestone | 0d | 2016-05-06 | 2016-05-06 | 39 |  |  | 0.33d | 0d | start no earlier than 2016-04-26 |  |  |  |
| 41 | 5 | All lab testing complete | milestone | 0d | 2016-05-06 | 2016-05-06 | 40 |  |  | 0.33d | 0d | start no earlier than 2016-02-02 |  |  |  |
| 42 | 6 | Assemble complete camera housing |  | 1.67d | 2016-05-09 | 2016-05-10 | 41, 11 |  |  | 0.33d |  | start no earlier than 2016-05-01 | François Cazenave [60%]; Mark Chaffey [60%] | 12.8h |  |
| 43 | 7 | **Tank testing with full vehicle running mission script** |  | 3d? | 2016-05-11 | 2016-05-13 |  |  |  |  |  |  |  | 66.4h |  |
| 44 | 7.1 | Assemble full AUV system |  | 1d | 2016-05-11 | 2016-05-11 | 42 |  |  | 0d |  |  | AUV tech; François Cazenave [60%]; Mark Chaffey [60%] | 17.6h |  |
| 45 | 7.2 | Verify mission scripts |  | 1d | 2016-05-12 | 2016-05-12 | 44 |  |  | 0d |  | start no earlier than 2016-02-02 | Rob McEwen; Rich Henthorn [60%]; Mark Chaffey [60%] | 17.6h |  |
| 46 | 7.3 | Confirm all camera operations |  | 1d | 2016-05-12 | 2016-05-12 | 44 |  |  | 0d |  | start no earlier than 2016-02-02 | Rob McEwen [20%]; Rich Henthorn [60%]; Mark Chaffey [60%] | 5.6h |  |
| 47 | 7.4 | Verify lighting is optimized |  | 1d? | 2016-05-12 | 2016-05-12 | 44 |  |  | 0d |  | start no earlier than 2016-05-11 | François Cazenave [60%]; Kim Reisenbichler; Mark Chaffey [60%] | 17.6h |  |
| 48 | 7.5 | Ballast and Trim |  | 1d? | 2016-05-12 | 2016-05-12 | 44 |  |  | 0d |  | start no earlier than 2016-05-11 | AUV tech | 8h |  |
| 49 | 7.6 | Tank testing complete | milestone | 0d | 2016-05-12 | 2016-05-12 | 48, 46, 47, 45 |  |  | 0d |  | start no earlier than 2016-02-02 |  |  |  |
| 50 | 8 | Load AUV for cruise |  | 1d | 2016-05-13 | 2016-05-13 | 49 |  |  | 0d |  |  | AUV tech | 8h |  |
| 51 | 9 | 1st transect intercomparison cruise | milestone | 0d | 2016-05-16 | 2016-05-16 | 50 |  |  | 0d |  | must start on 2016-05-16 |  |  |  |
| 52 | 10 | Backup Cruise date | milestone | 0d | 2016-06-01 | 2016-06-01 |  |  |  | 138d |  | start no earlier than 2016-06-01 |  |  |  |
| 53 | 11 | 2nd transect intercomparison cruise | milestone | 0d | 2016-06-06 | 2016-06-06 |  |  |  | 135d |  | start no earlier than 2016-06-06 |  |  |  |
| 54 | 12 | 3rd transect intercomparison cruise | milestone | 0d | 2016-09-15 | 2016-09-15 |  |  |  | 62d |  | start no earlier than 2016-09-15 |  |  |  |
| 55 | 13 | 4th transect intercomparison cruise | milestone | 0d | 2016-11-07 | 2016-11-07 |  |  |  | 25d |  | start no earlier than 2016-11-07 |  |  |  |
| 56 | 14 | 5th transect intercomparison cruise | milestone | 0d | 2016-12-12 | 2016-12-12 |  |  |  | 0d |  | start no earlier than 2016-12-12 |  |  |  |
