# I2MAP_EngineeringSchedule

Schedule from MS Project, 2014-01-01 to 2014-12-15, A marks actual dates.
Hewlett-Packard Company

## Calendars

- Standard: Mon-Fri 08:00-12:00, 13:00-17:00; Sat-Sun off. Exceptions (off unless hours are given): 2014-04-05 08:00-12:00, 13:00-17:00.

## Resources

| Resource |
| --- |
| Mark Chaffey |
| Rich Henthorn |
| François Cazenave |
| Machine Shop |
| E Tech |
| M tech |
| Kim Reisenbichler |
| AUV tech |

## Schedule

| ID | Task | Type | Duration | Start | Finish | Predecessors | Complete | Remaining | Total slack | Free slack | Constraint | Resources | Work | Actual work |
| --- | --- | --- | --- | --- | --- | --- | --- | --- | --- | --- | --- | --- | --- | --- |
| 1 | Capture draft of design requirements |  | 17.13d | 2014-01-01 A | 2014-01-27 |  | 85% | 2.57d | 159d | 29.5d |  | Mark Chaffey [60%] | 82.22h | 69.89h |
| 2 | Research camera and recorder options |  | 19d | 2014-01-06 A | 2014-02-11 |  | 75% | 4.75d | 129.5d | 0d | start no earlier than 2014-01-06 | Mark Chaffey [60%] | 48h | 43.04h |
| 3 | Select top three camera and recorder options |  | 2d | 2014-02-11 | 2014-02-13 | 2 |  |  | 129.5d | 0d |  | Mark Chaffey [60%] | 9.6h |  |
| 4 | Document workflow path for each camera and recorder option |  | 3d | 2014-02-25 | 2014-02-28 | 3 |  |  | 134.5d | 5d |  | Mark Chaffey [60%] | 14.4h |  |
| 5 | Document recorder and AUV interfaces for each camera option |  | 3d | 2014-02-20 | 2014-02-25 | 3 |  |  | 137.5d | 8d | start no earlier than 2014-01-26 | Mark Chaffey [60%] | 14.4h |  |
| 6 | Investigate camera control interface for each camera option |  | 4d | 2014-02-11 | 2014-02-17 | 2 |  |  | 143.5d | 14d |  | Rich Henthorn [60%] | 19.2h |  |
| 7 | Draft optical design specification and lens selection |  | 5d | 2014-02-13 | 2014-02-20 | 3 |  |  | 129.5d | 0d | start no earlier than 2014-01-29 | Mark Chaffey [60%] | 24h |  |
| 8 | Identify optical consulant |  | 2d | 2014-03-05 | 2014-03-07 | 7 |  |  | 129.5d | 0d |  | Mark Chaffey [60%] | 9.6h |  |
| 9 | Preliminary mechanical layout of lights, sensors and camera options |  | 3d | 2014-02-28 | 2014-03-05 | 7 |  |  | 131.5d | 2d |  | François Cazenave [60%]; Mark Chaffey [60%] | 12.8h |  |
| 10 | Concept design review | milestone | 0d | 2014-03-07 | 2014-03-07 | 3, 8, 1, 9, 5, 4, 6 |  |  | 129.5d | 0d |  | Mark Chaffey [60%]; Kim Reisenbichler; François Cazenave [60%] |  |  |
| 11 | Design and construct camera test rig |  | 5d | 2014-03-07 | 2014-03-14 | 10 |  |  | 129.5d | 0d |  | Mark Chaffey [60%]; M tech | 64h |  |
| 12 | Test three camera options |  | 10d | 2014-03-14 | 2014-03-28 | 11 |  |  | 129.5d | 0d |  | Mark Chaffey [60%] | 48h |  |
| 13 | Evaluate camera test results |  | 5d | 2014-03-28 | 2014-04-04 | 12 |  |  | 129.5d | 0d |  | Mark Chaffey [60%]; Kim Reisenbichler | 64h |  |
| 14 | NAB Show | manual | 5d | 2014-04-05 | 2014-04-10 |  |  |  |  |  | start no earlier than 2014-04-05 |  |  |  |
| 15 | Select optimal camera system |  | 2d | 2014-04-11 | 2014-04-14 | 13, 14 |  |  | 124d | 0d |  |  |  |  |
| 16 | Preliminary design review | milestone | 0d | 2014-04-14 | 2014-04-14 | 15, 14 |  |  | 124d | 0d |  | Kim Reisenbichler; François Cazenave [60%]; Mark Chaffey [60%] |  |  |
| 17 | Specify AUV minimum speed | milestone | 0d | 2014-04-14 | 2014-04-14 | 15 |  |  | 174d |  |  |  |  |  |
| 18 | Complete system design |  | 5d | 2014-04-15 | 2014-04-21 | 15 |  |  | 169d |  |  |  |  |  |
| 19 | Final schematics for camera and sensor payload |  | 5d | 2014-04-15 | 2014-04-21 | 16 |  |  | 169d |  |  |  |  |  |
| 20 | Final Optical design |  | 10d | 2014-04-15 | 2014-04-28 | 16 |  |  | 124d | 0d |  | Mark Chaffey [60%] | 8h |  |
| 21 | Housing mechanical design |  | 10d | 2014-04-15 | 2014-04-28 | 20FF |  |  | 124d | 0d |  | François Cazenave [60%] | 48h |  |
| 22 | Purchase camera, lens, recorder and sensor instrumentation |  | 1.67d | 2014-04-29 | 2014-04-30 | 16, 21, 20 |  |  | 142.33d | 18.33d |  | Mark Chaffey [60%]; Kim Reisenbichler | 16h |  |
| 23 | Purchase cables and penetrators | manual | 30d | 2014-01-01 | 2014-02-12 |  |  |  |  |  |  |  |  |  |
| 24 | Purchase and fabricate optical components |  | 20d | 2014-04-29 | 2014-05-26 | 20 |  |  | 124d | 0d |  | Mark Chaffey [60%] | 8h |  |
| 25 | Fabricate mechanical components |  | 20d | 2014-04-29 | 2014-05-26 | 21 |  |  | 124d | 0d |  | Machine Shop; François Cazenave [60%] | 200h |  |
| 26 | Assemble and integrate complete nose cone |  | 10d | 2014-05-27 | 2014-06-09 | 25, 24, 22 |  |  | 124d | 0d |  | Mark Chaffey [60%]; François Cazenave [60%]; M tech; E Tech | 240h |  |
| 27 | Complete system laboratory testing |  | 5d | 2014-06-10 | 2014-06-16 | 26 |  |  | 124d | 0d |  | Kim Reisenbichler; Mark Chaffey [60%]; AUV tech | 104h |  |
| 28 | Sea trials |  | 5d | 2014-06-17 | 2014-06-23 | 27 |  |  | 124d |  |  | Kim Reisenbichler; Mark Chaffey [60%] | 64h |  |
| 29 | Dorado Low Speed Testing - low bouyancy | milestone | 0d | 2014-03-12 | 2014-03-12 |  |  |  | 199d |  | start no earlier than 2014-03-12 |  |  |  |
| 30 | Dorado Low Speed Testing - winged | milestone | 0d | 2014-03-13 | 2014-03-13 |  |  |  | 198d |  | start no earlier than 2014-03-13 |  |  |  |
| 31 | Imaging AUV sea trial 1 | milestone | 0d | 2014-09-29 | 2014-09-29 |  |  |  | 55d |  | start no earlier than 2014-09-29 |  |  |  |
| 32 | Imaging AUV sea trial 2 | milestone | 0d | 2014-11-04 | 2014-11-04 |  |  |  | 29d |  | start no earlier than 2014-11-04 |  |  |  |
| 33 | Imaging AUV sea trial 3 | milestone | 0d | 2014-12-15 | 2014-12-15 |  |  |  | 0d |  | start no earlier than 2014-12-15 |  |  |  |
