# I2MAP_EngineeringScheduleVerKRR

Schedule from MS Project, 2014-01-01 to 2014-12-17, A marks actual dates.
Hewlett-Packard Company

## Calendars

- Standard: Mon-Fri 08:00-12:00, 13:00-17:00; Sat-Sun off. Exceptions (off unless hours are given): 2014-04-05 08:00-12:00, 13:00-17:00.

## Resources

| Resource |
| --- |
| Mark Chaffey |
| Rich Henthorn |
| François Cazenave |
| Machine Shop |
| E Tech |
| M tech |
| Kim Reisenbichler |
| AUV tech |
| Consultant |

## Schedule

| ID | Task | Type | Duration | Start | Finish | Predecessors | Complete | Remaining | Total slack | Free slack | Constraint | Resources | Work | Actual work |
| --- | --- | --- | --- | --- | --- | --- | --- | --- | --- | --- | --- | --- | --- | --- |
| 1 | Capture draft of design requirements |  | 17.13d | 2014-01-01 A | 2014-01-27 A |  | 100% |  |  |  |  | Mark Chaffey [60%] | 82.22h | 82.22h |
| 2 | Research camera and recorder options |  | 19d | 2014-01-06 A | 2014-02-11 A |  | 100% |  |  |  | start no earlier than 2014-01-06 | Mark Chaffey [60%] | 48h | 48h |
| 3 | Select top three camera and recorder options |  | 2d | 2014-02-11 A | 2014-02-13 A | 2 | 100% |  |  |  |  | Mark Chaffey [60%] | 9.6h | 9.6h |
| 4 | Document workflow path for each camera and recorder option |  | 3d | 2014-02-25 A | 2014-02-28 A | 3 | 100% |  |  |  |  | Mark Chaffey [60%] | 14.4h | 14.4h |
| 5 | Document recorder and AUV interfaces for each camera option |  | 3d | 2014-02-20 A | 2014-02-25 A | 3 | 100% |  |  |  | start no earlier than 2014-01-26 | Mark Chaffey [60%] | 14.4h | 14.4h |
| 6 | Investigate camera control interface for each camera option |  | 4d | 2014-02-11 A | 2014-02-17 A | 2 | 100% |  |  |  |  | Rich Henthorn [60%] | 19.2h | 19.2h |
| 7 | Draft optical design specification and lens selection |  | 5d | 2014-02-13 A | 2014-02-20 A | 3 | 100% |  |  |  | start no earlier than 2014-01-29 | Mark Chaffey [60%] | 24h | 24h |
| 8 | Identify optical consulant |  | 2d | 2014-08-11 | 2014-08-12 | 7 |  |  | 38d | 5d | start no earlier than 2014-08-10 | Mark Chaffey [60%] | 9.6h |  |
| 9 | Preliminary mechanical layout of lights, sensors and camera options |  | 3d | 2014-02-28 A | 2014-03-05 A | 7 | 100% |  |  |  |  | François Cazenave [60%]; Mark Chaffey [60%] | 12.8h | 12.8h |
| 10 | Concept design review | milestone | 0d | 2014-04-24 | 2014-04-24 | 3, 1, 9, 5, 4, 6 |  |  | 167d |  | start no earlier than 2014-04-24 | Mark Chaffey [60%]; Kim Reisenbichler; François Cazenave [60%] |  |  |
| 11 | Dorado Low Speed Testing - low bouyancy | milestone | 0d | 2014-03-12 | 2014-03-12 |  |  |  | 199d |  | start no earlier than 2014-03-12 |  |  |  |
| 12 | Dorado Low Speed Testing - winged | milestone | 0d | 2014-03-13 | 2014-03-13 |  |  |  | 198d |  | start no earlier than 2014-03-13 |  |  |  |
| 13 | Design and construct camera test rig |  | 5d | 2014-06-09 A | 2014-06-13 A | 10 | 100% |  |  |  | finish no earlier than 2014-06-13 | Mark Chaffey [60%]; M tech | 64h | 64h |
| 14 | Test three camera options |  | 25d | 2014-06-16 A | 2014-07-18 A | 13 | 100% |  |  |  |  | Mark Chaffey [60%] | 120h | 120h |
| 15 | Evaluate camera test results |  | 5d | 2014-07-21 A | 2014-07-25 | 14 | 75% | 1.25d | 100d |  | finish no earlier than 2014-07-22 | Mark Chaffey [60%]; Kim Reisenbichler | 64h | 48h |
| 16 | Select optimal camera system |  | 2d | 2014-07-28 A | 2014-07-29 A | 15 | 100% |  |  |  |  |  |  |  |
| 17 | Complete system design |  | 13d | 2014-07-30 A | 2014-08-15 A | 16 | 100% |  |  |  |  |  |  |  |
| 18 | Specify AUV minimum speed | milestone | 0d | 2014-07-29 | 2014-07-29 | 16 |  |  | 98d |  |  |  |  |  |
| 19 | Preliminary design review | milestone | 0d | 2014-08-20 | 2014-08-20 | 16, 8, 17 |  |  | 33d | 0d | start no earlier than 2014-08-20 | Kim Reisenbichler; François Cazenave [60%]; Mark Chaffey [60%] |  |  |
| 20 | Purchase camera, lens, recorder and sensor instrumentation |  | 25d | 2014-08-20 | 2014-09-23 | 19 |  |  | 35d |  |  | Mark Chaffey [60%]; Kim Reisenbichler | 128h |  |
| 21 | Final schematics for camera and sensor payload |  | 15d | 2014-08-20 | 2014-09-09 | 19 |  |  | 15d | 0d |  | Mark Chaffey [60%] | 72h |  |
| 22 | Fabricate camera I/O adapter board |  | 15d | 2014-09-10 | 2014-09-30 | 21 |  |  | 30d |  |  | Mark Chaffey [60%]; E Tech | 122h |  |
| 23 | Contract optical design | milestone | 0d | 2014-09-03 | 2014-09-03 |  |  |  | 0d |  | must start on 2014-09-03 |  |  |  |
| 24 | Final Optical design |  | 20d | 2014-09-03 | 2014-09-30 | 19, 23 |  |  | 0d |  |  | Mark Chaffey [20%]; Consultant; François Cazenave [40%] | 256h |  |
| 25 | Housing mechanical design |  | 15d | 2014-09-10 | 2014-09-30 | 24FF |  |  | 10d | 0d |  | François Cazenave [60%] | 72h |  |
| 26 | Purchase cables and penetrators | manual | 30d | 2014-09-10 | 2014-10-21 | 21 |  |  |  |  |  | Mark Chaffey [60%] | 8h |  |
| 27 | Purchase and fabricate optical components |  | 30d | 2014-10-01 | 2014-11-11 | 24 |  |  | 0d |  |  | Mark Chaffey [60%] | 144h |  |
| 28 | Fabricate mechanical components |  | 20d | 2014-10-01 | 2014-10-28 | 25 |  |  | 10d | 0d |  | Machine Shop; François Cazenave [60%] | 200h |  |
| 29 | Assemble camera housing |  | 3d | 2014-11-12 | 2014-11-14 | 22, 20, 26, 27, 28 |  |  | 0d |  |  | Mark Chaffey [60%]; François Cazenave [60%]; E Tech | 52.8h |  |
| 30 | Optical test housing and lighting |  | 3d | 2014-11-17 | 2014-11-19 | 29 |  |  | 0d |  |  | François Cazenave [60%]; Mark Chaffey [60%] | 28.8h |  |
| 31 | Pressure test housing |  | 2d | 2014-10-29 | 2014-10-30 | 28 |  |  | 14d |  |  | François Cazenave [60%] | 9.6h |  |
| 32 | Assemble and integrate complete nose cone |  | 10d | 2014-11-20 | 2014-12-03 | 28, 27, 20, 31, 30 |  |  | 0d |  |  | Mark Chaffey [60%]; François Cazenave [60%]; M tech; E Tech | 240h |  |
| 33 | Complete system laboratory testing |  | 5d | 2014-12-04 | 2014-12-10 | 32 |  |  | 0d |  |  | Kim Reisenbichler; Mark Chaffey [60%]; AUV tech; Rich Henthorn [60%] | 128h |  |
| 34 | Sea trials |  | 5d | 2014-12-11 | 2014-12-17 | 33 |  |  | 0d |  |  | Kim Reisenbichler; Mark Chaffey [60%] | 64h |  |
| 35 | Imaging AUV sea trial 1--> 2 knot Stability Test | milestone | 0d | 2014-09-29 | 2014-09-29 |  |  |  | 58d |  | start no earlier than 2014-09-29 |  |  |  |
| 36 | Imaging AUV sea trial 2 -->ROV base Cam Testing | milestone | 0d | 2014-11-04 | 2014-11-04 |  |  |  | 32d |  | start no earlier than 2014-11-04 |  |  |  |
| 37 | Imaging AUV sea trial 3-->First System Sea Trial | milestone | 0d | 2014-12-15 | 2014-12-15 |  |  |  | 3d |  | start no earlier than 2014-12-15 |  |  |  |
