# I2MAP_EngineeringScheduleVerKRR2

Schedule from MS Project, 2014-01-01 to 2015-09-11, A marks actual dates.
Hewlett-Packard Company

## Calendars

- Standard: Mon-Fri 08:00-12:00, 13:00-17:00; Sat-Sun off. Exceptions (off unless hours are given): 2014-04-05 08:00-12:00, 13:00-17:00.

## Resources

| Resource |
| --- |
| Mark Chaffey |
| Rich Henthorn |
| François Cazenave |
| Machine Shop |
| E Tech |
| M tech |
| Kim Reisenbichler |
| AUV tech |
| Consultant |
| Brantner and SubConn |

## Schedule

| ID | WBS | Task | Type | Duration | Start | Finish | Predecessors | Complete | Remaining | Total slack | Free slack | Constraint | Resources | Work | Actual work |
| --- | --- | --- | --- | --- | --- | --- | --- | --- | --- | --- | --- | --- | --- | --- | --- |
| 1 | 1 | Capture draft of design requirements |  | 17.13d | 2014-01-01 A | 2014-01-27 A |  | 100% |  |  |  |  | Mark Chaffey [60%] | 82.22h | 82.22h |
| 2 | 2 | Research camera and recorder options |  | 19d | 2014-01-06 A | 2014-02-11 A |  | 100% |  |  |  | start no earlier than 2014-01-06 | Mark Chaffey [60%] | 48h | 48h |
| 3 | 3 | Select top three camera and recorder options |  | 2d | 2014-02-11 A | 2014-02-13 A | 2 | 100% |  |  |  |  | Mark Chaffey [60%] | 9.6h | 9.6h |
| 4 | 4 | Document workflow path for each camera and recorder option |  | 3d | 2014-02-25 A | 2014-02-28 A | 3 | 100% |  |  |  |  | Mark Chaffey [60%] | 14.4h | 14.4h |
| 5 | 5 | Document recorder and AUV interfaces for each camera option |  | 3d | 2014-02-20 A | 2014-02-25 A | 3 | 100% |  |  |  | start no earlier than 2014-01-26 | Mark Chaffey [60%] | 14.4h | 14.4h |
| 6 | 6 | Investigate camera control interface for each camera option |  | 4d | 2014-02-11 A | 2014-02-17 A | 2 | 100% |  |  |  |  | Rich Henthorn [60%] | 19.2h | 19.2h |
| 7 | 7 | Draft optical design specification and lens selection |  | 5d | 2014-02-13 A | 2014-02-20 A | 3 | 100% |  |  |  | start no earlier than 2014-01-29 | Mark Chaffey [60%] | 24h | 24h |
| 8 | 8 | Identify optical consulant |  | 2d | 2014-08-11 A | 2014-08-12 A | 7 | 100% |  |  |  | start no earlier than 2014-08-10 | Mark Chaffey [60%] | 9.6h | 9.6h |
| 9 | 9 | Preliminary mechanical layout of lights, sensors and camera options |  | 3d | 2014-02-28 A | 2014-03-05 A | 7 | 100% |  |  |  |  | François Cazenave [60%]; Mark Chaffey [60%] | 12.8h | 12.8h |
| 10 | 10 | Concept design review | milestone | 0d | 2014-04-24 A | 2014-04-24 A | 3, 1, 9, 5, 4, 6 | 100% |  |  |  | start no earlier than 2014-04-24 | Mark Chaffey [60%]; Kim Reisenbichler; François Cazenave [60%] |  |  |
| 11 | 11 | Dorado Low Speed Testing - low bouyancy | milestone | 0d | 2014-03-12 A | 2014-03-12 A |  | 100% |  |  |  | start no earlier than 2014-03-12 |  |  |  |
| 12 | 12 | Dorado Low Speed Testing - winged | milestone | 0d | 2014-03-13 A | 2014-03-13 A |  | 100% |  |  |  | start no earlier than 2014-03-13 |  |  |  |
| 13 | 13 | Design and construct camera test rig |  | 5d | 2014-06-09 A | 2014-06-13 A | 10 | 100% |  |  |  | finish no earlier than 2014-06-13 | Mark Chaffey [60%]; M tech | 64h | 64h |
| 14 | 14 | Test three camera options |  | 25d | 2014-06-16 A | 2014-07-18 A | 13 | 100% |  |  |  |  | Mark Chaffey [60%] | 120h | 120h |
| 15 | 15 | Evaluate camera test results |  | 5d | 2014-07-21 A | 2014-07-25 A | 14 | 100% |  |  |  | finish no earlier than 2014-07-22 | Mark Chaffey [60%]; Kim Reisenbichler | 64h | 64h |
| 16 | 16 | Select optimal camera system |  | 2d | 2014-07-28 A | 2014-07-29 A | 15 | 100% |  |  |  |  |  |  |  |
| 17 | 17 | Complete system design |  | 13d | 2014-07-30 A | 2014-08-15 A | 16 | 100% |  |  |  |  |  |  |  |
| 18 | 18 | Specify AUV minimum speed | milestone | 0d | 2014-07-29 | 2014-07-29 | 16 |  |  | 293d |  |  |  |  |  |
| 19 | 19 | Final schematics for camera and sensor payload |  | 15d | 2015-01-27 A | 2015-02-16 A | 20 | 100% |  |  |  | finish no earlier than 2015-02-16 | Mark Chaffey [60%] | 72h | 72h |
| 20 | 20 | Preliminary design review | milestone | 0d | 2014-08-20 A | 2014-08-20 A | 16, 8, 17 | 100% |  |  |  | start no earlier than 2014-08-20 | Kim Reisenbichler; François Cazenave [60%]; Mark Chaffey [60%] |  |  |
| 21 | 21 | Purchase camera, lens, recorder and sensor instrumentation |  | 25d | 2014-08-20 A | 2014-09-23 A | 20 | 100% |  |  |  |  | Mark Chaffey [60%]; Kim Reisenbichler | 128h | 128h |
| 22 | 22 | Imaging AUV sea trial 1--> 2 knot Stability Test | milestone | 0d | 2014-09-29 A | 2014-09-29 A |  | 100% |  |  |  | start no earlier than 2014-09-29 |  |  |  |
| 23 | 23 | Imaging AUV sea trial 2 -->Low-speed Stability testing | milestone | 0d | 2014-11-04 A | 2014-11-04 A |  | 100% |  |  |  | start no earlier than 2014-11-04 |  |  |  |
| 24 | 24 | Imaging AUV sea trial 3-->Further Stab Testing (2 Knot) | milestone | 0d | 2014-12-15 | 2014-12-15 |  |  |  | 195d |  | start no earlier than 2014-12-15 |  |  |  |
| 25 | 25 | Contract optical design | milestone | 0d | 2014-09-03 A | 2014-09-03 A |  | 100% |  |  |  | must start on 2014-09-03 |  |  |  |
| 26 | 26 | Final Optical design |  | 20d | 2014-12-04 A | 2014-12-31 A | 20, 25 | 100% |  |  |  | finish no earlier than 2014-12-31 | Mark Chaffey [20%]; Consultant; François Cazenave [40%] | 256h | 256h |
| 27 | 27 | Housing mechanical design |  | 15d | 2014-12-11 A | 2014-12-31 A | 26FF | 100% |  |  |  |  | François Cazenave [60%] | 72h | 72h |
| 28 | 28 | I/O Electronics and Chassis design review |  | 1d? | 2015-04-09 | 2015-04-09 |  |  |  | 81d | 0d | start no earlier than 2015-04-09 |  |  |  |
| 29 | 29 | Fabricate camera I/O adapter board |  | 20d | 2015-04-10 | 2015-05-07 | 19, 28 |  |  | 81d | 0d | finish no earlier than 2015-01-20 | Mark Chaffey [60%]; E Tech | 162h |  |
| 30 | 30 | Populate electronics board |  | 1d? | 2015-05-08 | 2015-05-08 | 29 |  |  | 81d | 0d |  |  |  |  |
| 31 | 31 | Machine camera housing chassis |  | 20d | 2015-04-10 | 2015-05-07 | 28 |  |  | 86d | 1d |  | Machine Shop [20%] | 32h |  |
| 32 | 32 | Camera housing wiring |  | 5d | 2015-05-11 | 2015-05-15 | 31, 30 |  |  | 85d |  |  | E Tech | 40h |  |
| 33 | 33 | Camera/recorder lab tests |  | 21d? | 2015-02-02 A | 2015-03-02 A |  | 100% |  |  |  | start no earlier than 2015-02-02 | Rich Henthorn [60%]; Mark Chaffey [60%] | 201.6h | 201.6h |
| 34 | 34 | Purchase cables and penetrators | manual | 15d | 2014-12-02 A | 2014-12-22 A | 19 | 100% |  |  |  |  | Mark Chaffey [60%] | 4h | 4h |
| 35 | 35 | Syntactic foam ordered |  | 1d? | 2014-12-23 A | 2014-12-23 A |  | 100% |  |  |  | start no earlier than 2014-12-23 | François Cazenave [60%] | 4.8h | 4.8h |
| 36 | 36 | Syntactic foam delivered |  | 1d? | 2015-02-13 A | 2015-02-13 A | 35 | 100% |  |  |  | start no earlier than 2015-02-13 | François Cazenave [60%] | 4.8h | 4.8h |
| 37 | 37 | Cables and penetrators arrive |  | 13d | 2015-02-02 A | 2015-02-18 A | 34 | 100% |  |  |  | finish no earlier than 2015-02-18 | Brantner and SubConn | 104h | 104h |
| 38 | 38 | Purchase and fabricate optical components |  | 65d | 2015-01-26 A | 2015-04-24 | 26 | 75% | 16.25d | 80d | 0d | finish no earlier than 2015-04-24 | Mark Chaffey [60%] | 312h | 234h |
| 39 | 39 | Fabricate mechanical components |  | 23d | 2015-02-11 A | 2015-03-13 | 27 | 75% | 5.75d | 110d | 32d | finish no earlier than 2015-03-13 | Machine Shop; François Cazenave [60%] | 224h | 178h |
| 40 | 40 | Assemble AUV nose cone |  | 3d? | 2015-04-30 | 2015-05-04 | 39 |  |  | 93.25d | 0d | start no earlier than 2015-04-30 | François Cazenave | 24h |  |
| 41 | 41 | Assemble instrument package |  | 3d? | 2015-03-19 A | 2015-05-05 | 40 | 75% | 0.75d? | 93.25d |  | start no earlier than 2014-03-19 | François Cazenave | 24h | 18h |
| 42 | 42 | Machine housing dome adapter |  | 23d | 2015-01-14 A | 2015-02-13 A | 26 | 100% |  |  |  | start no earlier than 2015-01-14 | Machine Shop | 184h | 184h |
| 43 | 43 | Optical component assembly - Boston |  | 3d? | 2015-04-27 | 2015-04-29 | 38 |  |  | 97d |  | finish no earlier than 2015-04-08 | François Cazenave [60%] | 14.4h |  |
| 44 | 44 | Dome and housing pressure test |  | 6d | 2015-04-29 | 2015-05-06 | 39 |  |  | 80d | 13d | finish no earlier than 2015-05-06 | François Cazenave [60%] | 28.8h |  |
| 45 | 45 | Assemble camera housing |  | 3d | 2015-05-07 | 2015-05-11 | 21, 34, 38, 39, 42 |  |  | 72d | 0d | start no earlier than 2015-05-07 | Mark Chaffey [60%]; François Cazenave [60%]; E Tech | 52.8h |  |
| 46 | 46 | Optical test housing and lighting |  | 3d | 2015-05-12 | 2015-05-14 | 45 |  |  | 72d | 5d |  | François Cazenave [60%]; Mark Chaffey [60%] | 28.8h |  |
| 47 | 47 | Complete system laboratory testing |  | 5d | 2015-05-15 | 2015-05-21 |  |  |  | 67d | 0d | start no earlier than 2015-05-15 | Kim Reisenbichler; Mark Chaffey [60%]; AUV tech; Rich Henthorn [60%] | 128h |  |
| 48 | 48 | Test Tank Camera/lighting tests |  | 2d | 2015-05-22 | 2015-05-25 | 46, 47 |  |  | 67d | 0d |  |  |  |  |
| 49 | 49 | Assemble and integrate complete nose cone |  | 5d | 2015-05-26 | 2015-06-01 | 39, 38, 21, 44, 46, 48 |  |  | 67d | 0d |  | Mark Chaffey [60%]; François Cazenave [60%]; M tech; E Tech | 128h |  |
| 50 | 50 | Develop rough AJA & Modronix interfaces - integrate into CARL server |  | 11d? | 2015-01-02 | 2015-01-16 |  |  |  | 135d | 5d | start no earlier than 2015-01-02 | Rich Henthorn [20%] | 17.6h |  |
| 51 | 51 | Test Data Pathways from AJA & Modtronix while fleshing out commands and logging functions |  | 29d? | 2015-01-26 | 2015-03-05 | 50 |  |  | 136d |  | finish no earlier than 2015-03-05 | Rich Henthorn [20%] | 46.4h |  |
| 52 | 52 | Create CARL behavior class for controling the CARL system when scripting missions |  | 26d? | 2015-02-12 | 2015-03-19 | 50 |  |  | 117d | 36d | finish no earlier than 2015-03-19 | Rich Henthorn [60%] | 124.8h |  |
| 53 | 53 | Test CARL subsystem with complete electronics |  | 9d? | 2015-05-11 | 2015-05-21 | 29, 30, 52 |  |  | 81d |  | finish no earlier than 2015-04-02 | Rich Henthorn [60%] | 43.2h |  |
| 54 | 54 | Ensure that all required commands and settings can be controlled via CARL software |  | 15d? | 2015-03-23 | 2015-04-10 |  |  |  | 110d |  | finish no earlier than 2015-04-10 | Rich Henthorn [60%] | 72h |  |
| 55 | 55 | Develop stand-alone test application that exercises all CARL controls |  | 25d? | 2015-03-09 | 2015-04-10 |  |  |  | 110d |  | finish no earlier than 2015-04-10 | Rich Henthorn [60%] | 120h |  |
| 56 | 56 | Place a QNX virtual machine on a laptop that can run the application for testing |  | 11d? | 2015-04-02 | 2015-04-16 |  |  |  | 106d |  | finish no earlier than 2015-04-16 | Rich Henthorn [60%] | 52.8h |  |
| 57 | 57 | AUV Integration |  | 5d | 2015-06-02 | 2015-06-08 | 49 |  |  | 67d | 0d |  | Mark Chaffey [60%]; Kim Reisenbichler; Rich Henthorn [60%]; AUV tech; François Cazenave [60%] | 152h |  |
| 58 | 58 | Test tank buoyancy/trim adjustment |  | 1d? | 2015-06-09 | 2015-06-09 | 57 |  |  | 67d | 0d | start no earlier than 2015-04-30 |  |  |  |
| 59 | 59 | Sea trials |  | 1d? | 2015-06-10 | 2015-06-10 | 58 |  |  | 67d |  | start no earlier than 2015-05-01 |  |  |  |
| 60 | 60 | 1st Intra-vehicle transects comparison |  | 1d? | 2015-06-12 | 2015-06-12 |  |  |  | 65d |  | start no earlier than 2015-06-12 |  |  |  |
| 62 | 61 | 2nd Intra-vehicle transect comparisons |  | 1d? | 2015-09-11 | 2015-09-11 |  |  |  | 0d |  | start no earlier than 2015-09-11 |  |  |  |
